# PlanoEstruturalTCC

Schedule from MS Project, 2020-06-01 to 2020-12-03.

## Calendars

- Padrão: Mon-Fri 09:00-12:00, 13:00-18:00; Sat-Sun off.

## Resources

| Resource | Group |
| --- | --- |
| Bruna Cardoso Andrade | Desenvolvimento |
| Tarcio Carneiro de Carvalho | Desenvolvimento |
| Leonardo Sena do Vale da Silva | Desenvolvimento |
| Lucas Cassimiro Tranzillo Nogueira | Desenvolviemento |
| Vitor Carvalho Pontes | Desenvolvimento |
| Gabriel Luiz Santos de Santana | Desenvolvimento |
| Máquina Windows | Equipamento |
| Celular Android | Equipamento |
| Celular IOS | Equipamento |
| LucidChart | Equipamento |
| Diagrams | Equipamento |
| Visual Studio Code | Equipamento |

## Schedule

| ID | WBS | Task | Duration | Start | Finish | Predecessors | Total slack | Free slack | Constraint | Resources | Work |
| --- | --- | --- | --- | --- | --- | --- | --- | --- | --- | --- | --- |
| 1 | 1 | **Plataforma de gerenciamento para pedidos presenciais.** | 134d | 2020-06-01 | 2020-12-03 |  | 0d |  |  |  | 9256h |
| 2 | 1.1 | **Diagrama do Modelo de dados** | 36d | 2020-06-01 | 2020-07-20 |  | 22d |  |  |  | 952h |
| 3 | 1.1.1 | Descrição das funcionalidade dos módulos. | 5d | 2020-06-01 | 2020-06-05 |  | 119d | 0d | start no earlier than 2020-06-01 | Leonardo Sena do Vale da Silva; LucidChart; Máquina Windows | 40h |
| 4 | 1.1.2 | Definição do fluxo entre as aplicações. | 10d | 2020-06-08 | 2020-06-19 | 3 | 119d |  |  | Bruna Cardoso Andrade; Gabriel Luiz Santos de Santana; Leonardo Sena do Vale da Silva; Lucas Cassimiro Tranzillo Nogueira; Tarcio Carneiro de Carvalho; Vitor Carvalho Pontes | 480h |
| 5 | 1.1.3 | Definição do tipo de banco de dados. | 1d | 2020-06-22 | 2020-06-22 |  | 118d |  | start no earlier than 2020-06-22 | Bruna Cardoso Andrade; Gabriel Luiz Santos de Santana; Leonardo Sena do Vale da Silva; Lucas Cassimiro Tranzillo Nogueira; Tarcio Carneiro de Carvalho; Vitor Carvalho Pontes | 48h |
| 6 | 1.1.4 | Pesquisa de ferramentas para construção do diagrama. | 1d | 2020-06-23 | 2020-06-23 |  | 6d | 0d | start no earlier than 2020-06-23 | Gabriel Luiz Santos de Santana; Leonardo Sena do Vale da Silva; Tarcio Carneiro de Carvalho; Bruna Cardoso Andrade; Lucas Cassimiro Tranzillo Nogueira; Vitor Carvalho Pontes | 48h |
| 7 | 1.1.5 | Construção do Diagrama. | 14d | 2020-06-24 | 2020-07-13 | 6 | 6d |  | start no earlier than 2020-06-24 | Gabriel Luiz Santos de Santana; Leonardo Sena do Vale da Silva; Tarcio Carneiro de Carvalho | 336h |
| 8 | 1.1.6 | Buffer. | 5d | 2020-07-14 | 2020-07-20 |  | 95d |  | start no earlier than 2020-07-14 |  |  |
| 9 | 1.2 | **Módulo Mobile** | 82d | 2020-07-22 | 2020-11-12 | 7 | 0d |  |  |  | 3080h |
| 10 | 1.2.1 | **BackEnd** | 43d | 2020-07-22 | 2020-09-18 |  | 0d |  |  |  | 1448h |
| 11 | 1.2.1.1 | Configuração do ambiente. | 2d | 2020-07-22 | 2020-07-23 |  | 0d |  | start no earlier than 2020-07-22 | Bruna Cardoso Andrade; Gabriel Luiz Santos de Santana; Leonardo Sena do Vale da Silva; Lucas Cassimiro Tranzillo Nogueira; Máquina Windows; Tarcio Carneiro de Carvalho; Vitor Carvalho Pontes; Celular Android; Celular IOS; Visual Studio Code | 112h |
| 12 | 1.2.1.2 | Desenvolvimento da api. | 30d | 2020-07-24 | 2020-09-03 | 11 | 0d |  |  | Gabriel Luiz Santos de Santana; Tarcio Carneiro de Carvalho; Leonardo Sena do Vale da Silva; Celular Android; Celular IOS; Visual Studio Code | 960h |
| 13 | 1.2.1.3 | Conexão da api com o banco. | 3d | 2020-09-04 | 2020-09-08 | 12 | 54d | 0d |  | Tarcio Carneiro de Carvalho; Vitor Carvalho Pontes; Lucas Cassimiro Tranzillo Nogueira; Celular Android; Celular IOS; Visual Studio Code | 96h |
| 14 | 1.2.1.4 | Testes | 5d | 2020-09-09 | 2020-09-15 | 13 | 54d | 0d |  | Bruna Cardoso Andrade; Gabriel Luiz Santos de Santana; Leonardo Sena do Vale da Silva; Lucas Cassimiro Tranzillo Nogueira; Tarcio Carneiro de Carvalho; Vitor Carvalho Pontes; Celular Android; Celular IOS; Visual Studio Code | 280h |
| 15 | 1.2.1.5 | Buffer | 3d | 2020-09-16 | 2020-09-18 | 14 | 54d |  |  |  |  |
| 16 | 1.2.2 | **FrontEnd** | 50d | 2020-09-04 | 2020-11-12 | 12 | 0d |  |  |  | 1632h |
| 17 | 1.2.2.1 | Configuração do ambiente | 1d | 2020-09-04 | 2020-09-04 |  | 0d |  | start no earlier than 2020-08-10 | Bruna Cardoso Andrade; Gabriel Luiz Santos de Santana; Leonardo Sena do Vale da Silva; Lucas Cassimiro Tranzillo Nogueira; Tarcio Carneiro de Carvalho; Vitor Carvalho Pontes; Celular Android; Celular IOS; Visual Studio Code | 56h |
| 18 | 1.2.2.2 | Desenvolvimento da Views | 20d | 2020-09-07 | 2020-10-02 | 17 | 0d |  | start no earlier than 2020-08-11 | Bruna Cardoso Andrade; Vitor Carvalho Pontes; Celular Android; Celular IOS; Visual Studio Code | 480h |
| 19 | 1.2.2.3 | Integração dos protótipos com as Views. | 15d | 2020-10-05 | 2020-10-23 | 18 | 15d | 0d | start no earlier than 2020-09-08 | Bruna Cardoso Andrade; Gabriel Luiz Santos de Santana; Vitor Carvalho Pontes; Celular Android; Celular IOS; Visual Studio Code | 480h |
| 20 | 1.2.2.4 | Integração das Views com as rotas da api. | 7d | 2020-10-26 | 2020-11-03 | 19 | 15d | 0d | start no earlier than 2020-09-29 | Bruna Cardoso Andrade; Gabriel Luiz Santos de Santana; Vitor Carvalho Pontes; Celular Android; Diagrams; Visual Studio Code | 224h |
| 21 | 1.2.2.5 | Testes. | 7d | 2020-11-04 | 2020-11-12 | 20 | 15d |  | start no earlier than 2020-09-08 | Bruna Cardoso Andrade; Gabriel Luiz Santos de Santana; Leonardo Sena do Vale da Silva; Lucas Cassimiro Tranzillo Nogueira; Tarcio Carneiro de Carvalho; Vitor Carvalho Pontes; Celular Android; Celular IOS; Visual Studio Code | 392h |
| 22 | 1.2.2.6 | Buffer. | 3d | 2020-09-17 | 2020-09-21 |  | 75d |  | start no earlier than 2020-09-17 |  |  |
| 23 | 1.3 | **Módulo Web** | 44d | 2020-10-05 | 2020-12-03 | 18 | 0d |  |  |  | 4080h |
| 24 | 1.3.1 | **BackEnd** | 39d | 2020-10-05 | 2020-11-26 |  | 0d |  |  |  | 1392h |
| 25 | 1.3.1.1 | Configuração do Ambiente | 1d | 2020-10-05 | 2020-10-05 |  | 0d |  | start no earlier than 2020-09-01 | Bruna Cardoso Andrade; Gabriel Luiz Santos de Santana; Leonardo Sena do Vale da Silva; Lucas Cassimiro Tranzillo Nogueira; Tarcio Carneiro de Carvalho; Vitor Carvalho Pontes; Celular Android; Celular IOS; Visual Studio Code | 56h |
| 26 | 1.3.1.2 | Desenvolvimento da api. | 15d | 2020-10-06 | 2020-10-26 | 25 | 0d |  | start no earlier than 2020-09-02 | Bruna Cardoso Andrade; Gabriel Luiz Santos de Santana; Lucas Cassimiro Tranzillo Nogueira; Celular Android; Celular IOS; Visual Studio Code | 480h |
| 27 | 1.3.1.3 | Conexão a api com banco de dados. | 3d | 2020-10-27 | 2020-10-29 | 26 | 5d | 0d | start no earlier than 2020-09-23 | Gabriel Luiz Santos de Santana; Leonardo Sena do Vale da Silva; Tarcio Carneiro de Carvalho; Máquina Windows; Visual Studio Code | 96h |
| 28 | 1.3.1.4 | Integração com o módulo mobile. | 15d | 2020-10-30 | 2020-11-19 | 27 | 5d | 0d | start no earlier than 2020-09-26 | Bruna Cardoso Andrade; Gabriel Luiz Santos de Santana; Tarcio Carneiro de Carvalho; Máquina Windows; Visual Studio Code | 480h |
| 29 | 1.3.1.5 | Testes. | 5d | 2020-11-20 | 2020-11-26 | 28 | 5d |  | start no earlier than 2020-10-17 | Bruna Cardoso Andrade; Gabriel Luiz Santos de Santana; Leonardo Sena do Vale da Silva; Lucas Cassimiro Tranzillo Nogueira; Tarcio Carneiro de Carvalho; Vitor Carvalho Pontes; Máquina Windows; Visual Studio Code | 280h |
| 30 | 1.3.1.6 | Buffer. | 3d | 2020-10-26 | 2020-10-28 |  | 26d |  | start no earlier than 2020-10-24 |  |  |

| ID | WBS | Task | Duration | Start | Finish | Predecessors | Total slack | Constraint | Resources | Work |
| --- | --- | --- | --- | --- | --- | --- | --- | --- | --- | --- |
| 31 | 1.3.2 | **FrontEnd** | 28d | 2020-10-27 | 2020-12-03 | 26 | 0d |  |  | 2688h |
| 32 | 1.3.2.1 | Configuração do ambiente. | 1d | 2020-10-27 | 2020-10-27 |  | 0d | start no earlier than 2020-09-21 | Bruna Cardoso Andrade; Gabriel Luiz Santos de Santana; Leonardo Sena do Vale da Silva; Lucas Cassimiro Tranzillo Nogueira; Tarcio Carneiro de Carvalho; Vitor Carvalho Pontes; Máquina Windows; Visual Studio Code | 56h |
| 33 | 1.3.2.2 | Desenvolvimento das WebViews | 20d | 2020-10-28 | 2020-11-24 | 32 | 7d | start no earlier than 2020-09-22 | Bruna Cardoso Andrade; Leonardo Sena do Vale da Silva; Vitor Carvalho Pontes; Gabriel Luiz Santos de Santana; Máquina Windows; Visual Studio Code | 800h |
| 34 | 1.3.2.3 | Integração dos protótipos com as WebViews. | 20d | 2020-10-28 | 2020-11-24 | 32 | 7d | start no earlier than 2020-09-20 | Bruna Cardoso Andrade; Gabriel Luiz Santos de Santana; Vitor Carvalho Pontes; Máquina Windows; Visual Studio Code | 640h |
| 35 | 1.3.2.4 | Integração das WebViews com as rotas da api. | 20d | 2020-10-28 | 2020-11-24 | 32 | 0d | start no earlier than 2020-10-10 | Bruna Cardoso Andrade; Leonardo Sena do Vale da Silva; Lucas Cassimiro Tranzillo Nogueira; Vitor Carvalho Pontes; Máquina Windows; Visual Studio Code | 800h |
| 36 | 1.3.2.5 | Testes. | 7d | 2020-11-25 | 2020-12-03 | 35 | 0d | start no earlier than 2020-10-21 | Bruna Cardoso Andrade; Gabriel Luiz Santos de Santana; Leonardo Sena do Vale da Silva; Lucas Cassimiro Tranzillo Nogueira; Tarcio Carneiro de Carvalho; Vitor Carvalho Pontes; Celular Android; Celular IOS; Máquina Windows; Visual Studio Code | 392h |
| 37 | 1.3.2.6 | Buffer. | 3d | 2020-10-30 | 2020-11-03 |  | 22d | start no earlier than 2020-10-30 |  |  |
| 38 | 1.4 | **Encerramento.** | 20d | 2020-11-03 | 2020-11-30 |  | 3d |  |  | 1144h |
| 39 | 1.4.1 | Validações de fluxo. | 7d | 2020-11-03 | 2020-11-11 |  | 16d | start no earlier than 2020-11-03 | Bruna Cardoso Andrade; Celular Android; Celular IOS; Lucas Cassimiro Tranzillo Nogueira; Máquina Windows; Tarcio Carneiro de Carvalho; Visual Studio Code; Vitor Carvalho Pontes | 280h |
| 40 | 1.4.2 | Validação com orientador técnico. | 4d | 2020-11-12 | 2020-11-17 |  | 12d | start no earlier than 2020-11-12 | Bruna Cardoso Andrade; Celular Android; Celular IOS; Gabriel Luiz Santos de Santana; Leonardo Sena do Vale da Silva; Lucas Cassimiro Tranzillo Nogueira; Máquina Windows; Tarcio Carneiro de Carvalho; Vitor Carvalho Pontes | 192h |
| 41 | 1.4.3 | Validação com orientador TheoPrax | 5d | 2020-11-12 | 2020-11-18 |  | 11d | start no earlier than 2020-11-12 | Bruna Cardoso Andrade; Celular Android; Celular IOS; Gabriel Luiz Santos de Santana; Leonardo Sena do Vale da Silva; Lucas Cassimiro Tranzillo Nogueira; Máquina Windows; Tarcio Carneiro de Carvalho; Vitor Carvalho Pontes | 240h |
| 42 | 1.4.4 | Correções e preparações para entrega. | 9d | 2020-11-18 | 2020-11-30 |  | 3d | start no earlier than 2020-11-18 | Bruna Cardoso Andrade; Gabriel Luiz Santos de Santana; Leonardo Sena do Vale da Silva; Lucas Cassimiro Tranzillo Nogueira; Tarcio Carneiro de Carvalho; Vitor Carvalho Pontes | 432h |
